# MyProject

Schedule from MS Project, 2003-02-03 to 2003-03-05.
We

## Calendars

- Standard: Mon-Fri 08:00-12:00, 13:00-17:00; Sat-Sun off.

## Resources

| Resource |
| --- |
| ap |
| sajal |

## Schedule

| ID | WBS | Task | Duration | Start | Finish | Predecessors | Total slack | Free slack | Resources | Work |
| --- | --- | --- | --- | --- | --- | --- | --- | --- | --- | --- |
| 1 | 1 | **Design** | 7d | 2003-02-03 | 2003-02-11 |  | 0d |  |  | 56h |
| 2 | 1.1 | Designing of SystemAdmin Module | 3d | 2003-02-03 | 2003-02-05 |  | 0d |  | ap | 24h |
| 3 | 1.2 | Modification Design in Existing | 2d | 2003-02-06 | 2003-02-07 | 2 | 12d | 0d | ap | 16h |
| 4 | 1.3 | Designing of Out look | 2d | 2003-02-10 | 2003-02-11 | 3 | 12d | 0d | ap | 16h |
| 5 | 2 | **Development** | 20d | 2003-02-06 | 2003-03-05 |  | 0d |  |  | 104h |
| 6 | 2.1 | SystemAdministrationModule | 6d | 2003-02-06 | 2003-02-13 | 2 | 0d |  | sajal | 48h |
| 7 | 2.2 | Updating Current VersionAccording to Changes needed | 4d | 2003-02-14 | 2003-02-19 | 6 | 0d |  | sajal | 32h |
| 8 | 2.3 | Updating the ProjectView to Languge independent | 3d | 2003-02-20 | 2003-02-24 | 7 | 0d |  | sajal | 24h |
| 9 | 2.4 | development of outlook | 5d | 2003-02-12 | 2003-02-18 | 4 | 9d | 0d |  |  |
| 10 | 2.5 | integration and testing | 2d | 2003-02-19 | 2003-02-20 | 9 | 9d |  |  |  |
| 11 | 2.6 | BugFixing | 7d | 2003-02-25 | 2003-03-05 | 8 | 0d |  |  |  |
| 12 | 2.7 | Testing | 3d | 2003-02-25 | 2003-02-27 | 8 | 4d |  |  |  |
